# ME_Machine_Monitoring_Project_Plan.draft 2

Schedule from MS Project, 2026-02-02 to 2026-12-09.

## Calendars

- Standard: Mon-Fri 08:00-12:00, 13:00-17:00; Sat-Sun off.

## Resources

| Resource |
| --- |
| James |
| Alex |
| Justin |
| Jacob |
| Martin |
| Pat |
| Team |

## Schedule

| ID | WBS | Task | Duration | Start | Finish | Predecessors | Baseline start | Baseline finish | Baseline duration | Total slack | Free slack | Resources | Work | Text1 |
| --- | --- | --- | --- | --- | --- | --- | --- | --- | --- | --- | --- | --- | --- | --- |
| 1 | 1 | **Applied Project Management Project Complete** | 223d | 2026-02-02 | 2026-12-09 |  |  |  |  | 0d |  |  | 4014h |  |
| 2 | 1.1 | Plan Team Kickoff Meeting | 3d | 2026-02-02 | 2026-02-04 |  | 2026-04-28 | 2026-04-30 | 3d | 0d |  | James | 24h | James |
| 3 | 1.2 | Team Kickoff Meeting | 1d | 2026-02-05 | 2026-02-05 | 2 | 2026-05-01 | 2026-05-01 | 1d | 0d |  | Team | 8h |  |
| 4 | 1.3 | **Pilot System** | 219d | 2026-02-06 | 2026-12-09 | 3 | 2026-05-04 | 2026-11-09 | 136d | 0d |  |  | 2086h |  |
| 5 | 1.3.1 | **Pilot Dashboard** | 23d | 2026-02-09 | 2026-03-11 |  | 2026-05-04 | 2026-05-29 | 20d | 20.75d | 15.75d |  | 144h |  |
| 6 | 1.3.1.1 | Define layout concept | 5d | 2026-02-09 | 2026-02-13 |  | 2026-05-04 | 2026-05-08 | 5d | 20.75d | 0d | James | 40h | James |
| 7 | 1.3.1.2 | Build application skeleton | 5d | 2026-02-16 | 2026-02-20 | 6 | 2026-05-11 | 2026-05-15 | 5d | 20.75d | 0d | James | 40h | James |
| 8 | 1.3.1.3 | Gather stakeholder feedback | 3d | 2026-02-23 | 2026-02-25 | 7 | 2026-05-18 | 2026-05-22 | 5d | 20.75d | 0d | James | 24h | James |
| 9 | 1.3.1.4 | Refine concept based on feedback | 5d | 2026-03-05 | 2026-03-11 | 8 | 2026-05-25 | 2026-05-29 | 5d | 20.75d |  | James | 40h | James |
| 10 | 1.3.2 | **Vibration Monitoring** | 54.75d | 2026-02-06 | 2026-04-23 |  | 2026-05-04 | 2026-08-11 | 71.25d | 5d |  |  | 408h |  |
| 11 | 1.3.2.1 | **Consult with WEG DSM team about WEGScan hardware** | 7.25d | 2026-02-06 | 2026-02-17 |  | 2026-05-04 | 2026-05-15 | 9.25d | 5d | 0d |  | 34h |  |
| 12 | 1.3.2.1.1 | Plan & Schedule meeting | 1d | 2026-02-06 | 2026-02-06 |  | 2026-05-04 | 2026-05-04 | 1d | 5d | 0d | James | 8h | James |
| 13 | 1.3.2.1.2 | Hold meeting | 2h | 2026-02-12 | 2026-02-12 | 12FS+3d | 2026-05-08 | 2026-05-08 | 2h | 5d | 0d | Team | 2h |  |
| 14 | 1.3.2.1.3 | Follow up discussions | 3d | 2026-02-12 | 2026-02-17 | 13 | 2026-05-08 | 2026-05-15 | 5d | 17d | 12d | Team | 24h |  |
| 15 | 1.3.2.2 | Follow recommended path for procurement | 2d | 2026-02-17 | 2026-02-19 | 11 | 2026-05-15 | 2026-05-19 | 2d | 209.75d |  | Alex | 16h | Alex |
| 16 | 1.3.2.3 | Lead time to receive first device(s) | 15d | 2026-02-12 | 2026-03-05 | 13 | 2026-05-19 | 2026-06-09 | 15d | 5d | 0d |  |  |  |
| 17 | 1.3.2.4 | Device familiarization - communications, data formats, measurement configurations | 10d | 2026-03-05 | 2026-03-19 | 16, 14 | 2026-06-09 | 2026-06-23 | 10d | 5d | 0d | Justin; Alex; Martin | 154h | James,Justin |
| 18 | 1.3.2.5 | Device Knowledge Sharing | 0.5d | 2026-03-19 | 2026-03-19 | 17 |  |  |  | 5d | 0d | Team | 4h |  |
| 19 | 1.3.2.6 | Define database structure for vibration data | 5d | 2026-03-19 | 2026-03-26 | 18 | 2026-06-23 | 2026-06-30 | 5d | 5d | 0d | James | 40h | James |
| 20 | 1.3.2.7 | Determine desired data flow from instrument to database | 5d | 2026-03-26 | 2026-04-02 | 19 | 2026-06-30 | 2026-07-14 | 10d | 5d | 0d | James | 40h | James |
| 21 | 1.3.2.8 | Integrate vibration data source into dashboard | 10d | 2026-04-02 | 2026-04-16 | 20, 5 | 2026-07-14 | 2026-07-28 | 10d | 5d | 0d | James | 80h | James |
| 22 | 1.3.2.9 | System latency testing & optimization | 5d | 2026-04-16 | 2026-04-23 | 21 | 2026-07-28 | 2026-08-11 | 10d | 5d | 0d | Justin | 40h | Justin |
| 23 | 1.3.3 | **Temperature Monitoring** | 97d | 2026-02-06 | 2026-06-22 |  | 2026-05-04 | 2026-08-24 | 81d | 10.38d |  |  | 416h |  |
| 24 | 1.3.3.1 | Web & vendor research for hardware options | 5d | 2026-02-06 | 2026-02-12 |  | 2026-05-04 | 2026-05-15 | 10d | 10.38d | 0d | Alex | 40h | Alex |
| 25 | 1.3.3.2 | Order hardware hardware for trial | 1d | 2026-02-13 | 2026-02-13 | 24 | 2026-05-18 | 2026-05-18 | 1d | 10.38d | 0d | Alex | 8h | Alex |
| 26 | 1.3.3.3 | Lead time to receive first device(s) | 15d | 2026-02-16 | 2026-03-06 | 25 | 2026-05-19 | 2026-06-08 | 15d | 10.38d | 0d |  |  |  |
| 27 | 1.3.3.4 | Device familiarization - communications, data formats, measurement configurations | 10d | 2026-03-20 | 2026-04-03 | 26 | 2026-06-09 | 2026-07-06 | 20d | 10.25d | 0d | Justin; Alex; Martin | 240h | James,Justin |
| 28 | 1.3.3.5 | Device Knowledge Sharing | 0.5d | 2026-04-03 | 2026-04-03 | 27 |  |  |  | 10.25d | 0d | Team | 4h |  |
| 29 | 1.3.3.6 | Define database structure for temperature data | 0.5d | 2026-05-07 | 2026-05-08 | 28 | 2026-07-07 | 2026-07-13 | 5d | 11d | 0d | James | 4h | James |
| 30 | 1.3.3.7 | Determine desired data flow from instrument to database | 5d | 2026-05-12 | 2026-05-18 | 29 | 2026-07-14 | 2026-07-27 | 10d | 13d | 0d | James | 40h | James |
| 31 | 1.3.3.8 | Integrate temperature data source into dashboard | 5d | 2026-06-09 | 2026-06-15 | 30, 5 | 2026-07-28 | 2026-08-10 | 10d | 13d | 0d | James | 40h | James |
| 32 | 1.3.3.9 | System latency testing | 5d | 2026-06-16 | 2026-06-22 | 31 | 2026-08-11 | 2026-08-24 | 10d | 13d | 0d | Justin | 40h | Justin |

| ID | WBS | Task | Type | Duration | Start | Finish | Predecessors | Baseline start | Baseline finish | Baseline duration | Total slack | Free slack | Resources | Work | Text1 |
| --- | --- | --- | --- | --- | --- | --- | --- | --- | --- | --- | --- | --- | --- | --- | --- |
| 33 | 1.3.4 | **Branch circuit Power Monitoring** |  | 219d | 2026-02-06 | 2026-12-09 |  | 2026-05-04 | 2026-08-07 | 69.25d | 0d |  |  | 358h |  |
| 34 | 1.3.4.1 | **Consult with Wisconsin Public Service (WPS) - offerings** |  | 12.5d | 2026-02-06 | 2026-02-24 |  | 2026-05-04 | 2026-05-19 | 11.25d | 0d |  |  | 50h |  |
| 35 | 1.3.4.1.1 | Plan & Schedule meeting |  | 1d | 2026-02-06 | 2026-02-06 |  | 2026-05-04 | 2026-05-04 | 1d | 0d |  | Jacob | 8h | Jacob |
| 36 | 1.3.4.1.2 | Hold meeting |  | 2h | 2026-02-17 | 2026-02-17 | 35FS+5d | 2026-05-12 | 2026-05-12 | 2h | 0d |  | Team | 2h |  |
| 37 | 1.3.4.1.3 | Follow up discussions |  | 5d | 2026-02-17 | 2026-02-24 | 36 | 2026-05-12 | 2026-05-19 | 5d | 0d |  | Team | 40h |  |
| 38 | 1.3.4.2 | Follow recommended path for procurement |  | 2d | 2026-02-24 | 2026-02-26 | 34 | 2026-05-19 | 2026-05-21 | 2d | 0d |  | Alex | 16h | Alex |
| 39 | 1.3.4.3 | Lead time to receive first device(s) |  | 15d | 2026-02-26 | 2026-03-19 | 38 | 2026-05-21 | 2026-06-11 | 15d | 0d |  |  |  |  |
| 40 | 1.3.4.4 | Device familiarization - communications, data formats, measurement configurations |  | 10d | 2026-04-03 | 2026-04-17 | 39 | 2026-06-11 | 2026-06-25 | 10d | 0d |  | Justin; Alex; Martin | 80h | James,Justin |
| 41 | 1.3.4.5 | Device Knowledge Sharing |  | 0.5d | 2026-04-17 | 2026-04-17 | 40 |  |  |  | 0d |  | Team | 4h |  |
| 42 | 1.3.4.6 | Define database structure for power data |  | 1d | 2026-06-24 | 2026-06-24 | 41 | 2026-06-25 | 2026-06-26 | 1d | 0d |  | James | 8h | James |
| 43 | 1.3.4.7 | Determine desired data flow from instrument to database |  | 10d | 2026-10-01 | 2026-10-14 | 42 | 2026-06-26 | 2026-07-10 | 10d | 0d |  | James | 80h | James |
| 44 | 1.3.4.8 | Integrate power data source into dashboard |  | 5d | 2026-10-21 | 2026-10-27 | 43, 5 | 2026-07-10 | 2026-07-24 | 10d | 0d |  | James | 40h | James |
| 45 | 1.3.4.9 | System latency testing & optimization |  | 10d | 2026-11-26 | 2026-12-09 | 44 | 2026-07-24 | 2026-08-07 | 10d | 0d |  | Justin | 80h | Justin |
| 46 | 1.3.5 | **MG Power Monitoring** |  | 209d | 2026-02-06 | 2026-11-25 |  | 2026-05-04 | 2026-11-09 | 136d | 10d |  |  | 760h |  |
| 47 | 1.3.5.1 | **Select monitoring solution** |  | 209d | 2026-02-06 | 2026-11-25 |  | 2026-05-04 | 2026-11-09 | 136d | 10d |  |  | 760h |  |
| 48 | 1.3.5.1.1 | **Shared Variables concept for machine monitoring** |  | 171d | 2026-02-26 | 2026-10-22 |  | 2026-05-04 | 2026-08-07 | 70d | 10d | 0d |  | 560h |  |
| 49 | 1.3.5.1.1.1 | Create shared variable engine test application |  | 1w | 2026-02-26 | 2026-03-04 |  | 2026-05-04 | 2026-05-08 | 1w | 10d | 0d | James | 40h | James |
| 50 | 1.3.5.1.1.2 | Create host application for publishing shared variables |  | 3w | 2026-04-16 | 2026-05-07 | 49 | 2026-05-11 | 2026-05-29 | 3w | 10d | 0d | James | 120h | James |
| 51 | 1.3.5.1.1.3 | Create server application for collecting shared variables |  | 3w | 2026-05-19 | 2026-06-08 | 50 | 2026-06-01 | 2026-06-19 | 3w | 10d | 0d | James | 120h | James |
| 52 | 1.3.5.1.1.4 | Build developmental 5E MG Starter application to publish shared variables |  | 5d | 2026-06-16 | 2026-06-22 | 51 | 2026-06-22 | 2026-06-26 | 5d | 10d | 0d | James | 40h | James |
| 53 | 1.3.5.1.1.5 | Update dyne application to publish Eaton drive parameter data stream |  | 20d | 2026-07-07 | 2026-08-03 | 52 | 2026-06-29 | 2026-07-24 | 20d | 10d | 0d | Justin | 160h | Justin |
| 54 | 1.3.5.1.1.6 | Update dyne application to publish Yokogowa data stream |  | 10d | 2026-10-09 | 2026-10-22 | 53 | 2026-07-27 | 2026-08-07 | 10d | 10d |  | Justin | 80h | Justin |
| 55 | 1.3.5.1.2 | **Panel mount power meter option** |  | 185d | 2026-02-06 | 2026-10-22 |  | 2026-05-04 | 2026-10-12 | 116d | 10d | 0d |  | 80h |  |
| 56 | 1.3.5.1.2.1 | Web & vendor research for hardware options |  | 10d | 2026-02-06 | 2026-02-19 |  | 2026-05-04 | 2026-05-15 | 10d | 185d | 175d | Justin | 80h | Justin |
| 57 | 1.3.5.1.2.2 | Order hardware hardware for trial | milestone | 0d | 2026-10-22 | 2026-10-22 | 56, 48 | 2026-08-10 | 2026-08-10 | 1d | 10d | 0d | Justin |  | Justin |
| 58 | 1.3.5.1.2.3 | Lead time to receive first device(s) | milestone | 0d | 2026-10-22 | 2026-10-22 | 57 | 2026-08-11 | 2026-08-31 | 15d | 10d | 0d |  |  |  |
| 59 | 1.3.5.1.2.4 | Device familiarization - communications, data formats, measurement configurations | milestone | 0d | 2026-10-22 | 2026-10-22 | 58 | 2026-09-01 | 2026-09-28 | 20d | 10d | 0d | Justin; Alex; Martin |  | James,Justin |
| 60 | 1.3.5.1.2.5 | Device Knowledge Sharing | milestone | 0d | 2026-10-22 | 2026-10-22 | 59 |  |  |  | 10d | 0d |  |  |  |
| 61 | 1.3.5.1.2.6 | Determine desired data flow from instrument to database | milestone | 0d | 2026-10-22 | 2026-10-22 | 60 | 2026-09-29 | 2026-10-12 | 10d | 10d |  | James |  | James |
| 62 | 1.3.5.1.3 | Integrate data source into dashboard |  | 10d | 2026-11-05 | 2026-11-18 | 48, 55, 5 | 2026-10-13 | 2026-10-26 | 10d | 10d | 0d | James | 80h | James |
| 63 | 1.3.5.1.4 | System latency testing |  | 5d | 2026-11-19 | 2026-11-25 | 62 | 2026-10-27 | 2026-11-09 | 10d | 10d |  | Justin | 40h | Justin |

| ID | WBS | Task | Duration | Start | Finish | Predecessors | Baseline start | Baseline finish | Baseline duration | Total slack | Free slack | Resources | Work | Text1 |
| --- | --- | --- | --- | --- | --- | --- | --- | --- | --- | --- | --- | --- | --- | --- |
| 64 | 1.4 | **System scaling** | 184.25d | 2026-03-19 | 2026-12-02 |  | 2026-08-07 | 2026-12-18 | 95.75d | 5d |  |  | 1896h |  |
| 65 | 1.4.1 | **Vibration monitoring** | 184.25d | 2026-03-19 | 2026-12-02 | 18 | 2026-08-11 | 2026-12-07 | 84d | 5d |  |  | 740h |  |
| 66 | 1.4.1.1 | **<12-2> 50 Hz MG Vibration** | 37.25d | 2026-03-19 | 2026-05-11 |  | 2026-08-11 | 2026-09-14 | 24d | 5d |  |  | 74h |  |
| 67 | 1.4.1.1.1 | <12-2> 50 Hz MG Vibration - Procure sensors | 0.25d | 2026-03-19 | 2026-03-19 |  | 2026-08-11 | 2026-09-01 | 15d | 14.75d | 0d | Alex | 2h | Alex |
| 68 | 1.4.1.1.2 | <12-2> 50 Hz MG Vibration - Lead Time | 15d | 2026-03-20 | 2026-04-09 | 67 |  |  |  | 14.75d | 9.75d |  |  |  |
| 69 | 1.4.1.1.3 | <12-2> 50 Hz MG Vibration - Install sensors | 1d | 2026-04-23 | 2026-04-24 | 68, 22 | 2026-09-01 | 2026-09-02 | 1d | 5d | 0d | Martin | 8h | Martin |
| 70 | 1.4.1.1.4 | <12-2> 50 Hz MG Vibration - Configure sensors | 1d | 2026-04-27 | 2026-04-28 | 69 | 2026-09-02 | 2026-09-03 | 1d | 5d | 0d | Alex | 8h | Justin |
| 71 | 1.4.1.1.5 | <12-2> 50 Hz MG Vibration - Configure dashboard | 1d | 2026-04-28 | 2026-04-29 | 70 | 2026-09-03 | 2026-09-04 | 1d | 5d | 0d | Alex | 8h | James |
| 72 | 1.4.1.1.6 | <12-2> 50 Hz MG Vibration - Record baseline data | 5d | 2026-05-04 | 2026-05-08 | 71 | 2026-09-04 | 2026-09-11 | 5d | 5d | 0d | Alex | 40h | Justin |
| 73 | 1.4.1.1.7 | <12-2> 50 Hz MG Vibration - Set alarm warning levels | 1d | 2026-05-11 | 2026-05-11 | 72 | 2026-09-11 | 2026-09-14 | 1d | 5d | 0d | James | 8h | James |
| 74 | 1.4.1.2 | **<4-3> 4E MG Vibration** | 68d | 2026-03-20 | 2026-06-23 |  | 2026-08-11 | 2026-09-14 | 24d | 5d |  |  | 74h |  |
| 75 | 1.4.1.2.1 | <4-3> 4E MG Vibration - Procure sensors - Pur. Req. | 0.25d | 2026-03-20 | 2026-03-20 | 67SS | 2026-08-11 | 2026-09-01 | 15d | 26.75d | 0d | Alex | 2h | Alex |
| 76 | 1.4.1.2.2 | <4-3> 4E MG Vibration - Procure sensors - Lead Time | 15d | 2026-03-20 | 2026-04-10 | 75 |  |  |  | 26.75d | 0d |  |  |  |
| 77 | 1.4.1.2.3 | <4-3> 4E MG Vibration - Install sensors | 1d | 2026-05-12 | 2026-05-12 | 76, 22, 73 | 2026-09-01 | 2026-09-02 | 1d | 5d | 0d | Martin | 8h | Martin |
| 78 | 1.4.1.2.4 | <4-3> 4E MG Vibration - Configure sensors | 1d | 2026-05-13 | 2026-05-13 | 77 | 2026-09-02 | 2026-09-03 | 1d | 5d | 0d | Alex | 8h | Justin |
| 79 | 1.4.1.2.5 | <4-3> 4E MG Vibration - Configure dashboard | 1d | 2026-05-14 | 2026-05-14 | 78 | 2026-09-03 | 2026-09-04 | 1d | 5d | 0d | Alex | 8h | James |
| 80 | 1.4.1.2.6 | <4-3> 4E MG Vibration - Record baseline data | 5d | 2026-05-15 | 2026-05-21 | 79 | 2026-09-04 | 2026-09-11 | 5d | 5d | 0d | Alex | 40h | Justin |
| 81 | 1.4.1.2.7 | <4-3> 4E MG Vibration - Set alarm warning levels | 1d | 2026-06-23 | 2026-06-23 | 80 | 2026-09-11 | 2026-09-14 | 1d | 5d | 0d | James | 8h | James |
| 82 | 1.4.1.3 | **<5-3> 5E MG Vibration** | 61.75d | 2026-04-10 | 2026-07-06 |  | 2026-09-01 | 2026-10-05 | 24d | 5d |  |  | 74h |  |
| 83 | 1.4.1.3.1 | <5-3> 5E MG Vibration - Procure sensors - Pur. Req. | 0.25d | 2026-04-10 | 2026-04-10 | 76 | 2026-09-01 | 2026-09-22 | 15d | 42.5d | 0d | Alex | 2h | Alex |
| 84 | 1.4.1.3.2 | <5-3> 5E MG Vibration - Procure sensors - Lead Time | 15d | 2026-04-10 | 2026-05-01 | 83 |  |  |  | 42.5d | 37.5d |  |  |  |
| 85 | 1.4.1.3.3 | <5-3> 5E MG Vibration - Install sensors | 1d | 2026-06-24 | 2026-06-24 | 84, 22, 81 | 2026-09-22 | 2026-09-23 | 1d | 5d | 0d | Martin | 8h | Martin |
| 86 | 1.4.1.3.4 | <5-3> 5E MG Vibration - Configure sensors | 1d | 2026-06-25 | 2026-06-25 | 85 | 2026-09-23 | 2026-09-24 | 1d | 5d | 0d | Alex | 8h | Justin |
| 87 | 1.4.1.3.5 | <5-3> 5E MG Vibration - Configure dashboard | 1d | 2026-06-26 | 2026-06-26 | 86 | 2026-09-24 | 2026-09-25 | 1d | 5d | 0d | Alex | 8h | James |
| 88 | 1.4.1.3.6 | <5-3> 5E MG Vibration - Record baseline data | 5d | 2026-06-29 | 2026-07-03 | 87 | 2026-09-25 | 2026-10-02 | 5d | 5d | 0d | Alex | 40h | Justin |
| 89 | 1.4.1.3.7 | <5-3> 5E MG Vibration - Set alarm warning levels | 1d | 2026-07-06 | 2026-07-06 | 88 | 2026-10-02 | 2026-10-05 | 1d | 5d | 0d | James | 8h | James |

Notes:
- 67: Purchase sensors for two pieces of equipment at a time to spread costs through time.
- 75: Purchase sensors for two pieces of equipment at a time to spread costs through time.
- 83: Purchase sensors for two pieces of equipment at a time to spread costs through time.

| ID | WBS | Task | Duration | Start | Finish | Predecessors | Baseline start | Baseline finish | Baseline duration | Total slack | Free slack | Resources | Work | Text1 |
| --- | --- | --- | --- | --- | --- | --- | --- | --- | --- | --- | --- | --- | --- | --- |
| 90 | 1.4.1.4 | **<6-3> 6E MG Vibration** | 73.5d | 2026-04-10 | 2026-07-22 |  | 2026-09-01 | 2026-10-05 | 24d | 5d |  |  | 74h |  |
| 91 | 1.4.1.4.1 | <6-3> 6E MG Vibration - Procure sensors - Pur. Req. | 0.25d | 2026-04-10 | 2026-04-10 | 83SS | 2026-09-01 | 2026-09-22 | 15d | 45.25d | 0d | Alex | 2h | Alex |
| 92 | 1.4.1.4.2 | <6-3> 6E MG Vibration - Procure sensors - Lead Time | 15d | 2026-04-10 | 2026-05-01 | 91 |  |  |  | 45.25d | 0d |  |  |  |
| 93 | 1.4.1.4.3 | <6-3> 6E MG Vibration - Install sensors | 1d | 2026-07-07 | 2026-07-07 | 92, 22, 89 | 2026-09-22 | 2026-09-23 | 1d | 5d | 0d | Martin | 8h | Martin |
| 94 | 1.4.1.4.4 | <6-3> 6E MG Vibration - Configure sensors | 1d | 2026-07-08 | 2026-07-08 | 93 | 2026-09-23 | 2026-09-24 | 1d | 5d | 0d | Alex | 8h | Justin |
| 95 | 1.4.1.4.5 | <6-3> 6E MG Vibration - Configure dashboard | 1d | 2026-07-09 | 2026-07-09 | 94 | 2026-09-24 | 2026-09-25 | 1d | 5d | 0d | Alex | 8h | James |
| 96 | 1.4.1.4.6 | <6-3> 6E MG Vibration - Record baseline data | 5d | 2026-07-15 | 2026-07-21 | 95 | 2026-09-25 | 2026-10-02 | 5d | 5d | 0d | Alex | 40h | Justin |
| 97 | 1.4.1.4.7 | <6-3> 6E MG Vibration - Set alarm warning levels | 1d | 2026-07-22 | 2026-07-22 | 96 | 2026-10-02 | 2026-10-05 | 1d | 5d | 0d | James | 8h | James |
| 98 | 1.4.1.5 | **<L53-4> 1W MG Vibration** | 67.25d | 2026-05-01 | 2026-08-04 |  | 2026-09-22 | 2026-10-26 | 24d | 5d |  |  | 74h |  |
| 99 | 1.4.1.5.1 | <L53-4> 1W MG Vibration - Procure sensors - Pur. Req. | 0.25d | 2026-05-01 | 2026-05-01 | 92 | 2026-09-22 | 2026-10-13 | 15d | 45.25d | 0d | Alex | 2h | Alex |
| 100 | 1.4.1.5.2 | <L53-4> 1W MG Vibration - Procure sensors - Lead Time | 15d | 2026-05-04 | 2026-05-22 | 99 |  |  |  | 48d | 43d |  |  |  |
| 101 | 1.4.1.5.3 | <L53-4> 1W MG Vibration - Install sensors | 1d | 2026-07-23 | 2026-07-23 | 100, 22, 97 | 2026-10-13 | 2026-10-14 | 1d | 5d | 0d | Martin | 8h | Martin |
| 102 | 1.4.1.5.4 | <L53-4> 1W MG Vibration - Configure sensors | 1d | 2026-07-24 | 2026-07-24 | 101 | 2026-10-14 | 2026-10-15 | 1d | 5d | 0d | Alex | 8h | Justin |
| 103 | 1.4.1.5.5 | <L53-4> 1W MG Vibration - Configure dashboard | 1d | 2026-07-27 | 2026-07-27 | 102 | 2026-10-15 | 2026-10-16 | 1d | 5d | 0d | Alex | 8h | James |
| 104 | 1.4.1.5.6 | <L53-4> 1W MG Vibration - Record baseline data | 5d | 2026-07-28 | 2026-08-03 | 103 | 2026-10-16 | 2026-10-23 | 5d | 5d | 0d | Alex | 40h | Justin |
| 105 | 1.4.1.5.7 | <L53-4> 1W MG Vibration - Set alarm warning levels | 1d | 2026-08-04 | 2026-08-04 | 104 | 2026-10-23 | 2026-10-26 | 1d | 5d | 0d | James | 8h | James |
| 106 | 1.4.1.6 | **<L52-4> 2W MG Vibration** | 70.75d | 2026-05-11 | 2026-08-17 |  | 2026-09-22 | 2026-10-26 | 24d | 5d |  |  | 74h |  |
| 107 | 1.4.1.6.1 | <L52-4> 2W MG Vibration - Procure sensors - Pur. Req. | 0.25d | 2026-05-11 | 2026-05-11 | 99SS | 2026-09-22 | 2026-10-13 | 15d | 45.25d | 0d | Alex | 2h | Alex |
| 108 | 1.4.1.6.2 | <L52-4> 2W MG Vibration - Procure sensors- Lead Time | 15d | 2026-05-11 | 2026-06-01 | 107 |  |  |  | 45.25d | 0d |  |  |  |
| 109 | 1.4.1.6.3 | <L52-4> 2W MG Vibration - Install sensors | 1d | 2026-08-05 | 2026-08-05 | 108, 22, 105 | 2026-10-13 | 2026-10-14 | 1d | 5d | 0d | Martin | 8h | Martin |
| 110 | 1.4.1.6.4 | <L52-4> 2W MG Vibration - Configure sensors | 1d | 2026-08-06 | 2026-08-06 | 109 | 2026-10-14 | 2026-10-15 | 1d | 5d | 0d | Alex | 8h | Justin |
| 111 | 1.4.1.6.5 | <L52-4> 2W MG Vibration - Configure dashboard | 1d | 2026-08-07 | 2026-08-07 | 110 | 2026-10-15 | 2026-10-16 | 1d | 5d | 0d | Alex | 8h | James |
| 112 | 1.4.1.6.6 | <L52-4> 2W MG Vibration - Record baseline data | 5d | 2026-08-10 | 2026-08-14 | 111 | 2026-10-16 | 2026-10-23 | 5d | 5d | 0d | Alex | 40h | Justin |
| 113 | 1.4.1.6.7 | <L52-4> 2W MG Vibration - Set alarm warning levels | 1d | 2026-08-17 | 2026-08-17 | 112 | 2026-10-23 | 2026-10-26 | 1d | 5d | 0d | James | 8h | James |

Notes:
- 91: Purchase sensors for two pieces of equipment at a time to spread costs through time.
- 99: Purchase sensors for two pieces of equipment at a time to spread costs through time.
- 107: Purchase sensors for two pieces of equipment at a time to spread costs through time.

| ID | WBS | Task | Duration | Start | Finish | Predecessors | Baseline start | Baseline finish | Baseline duration | Total slack | Free slack | Resources | Work | Text1 |
| --- | --- | --- | --- | --- | --- | --- | --- | --- | --- | --- | --- | --- | --- | --- |
| 114 | 1.4.1.7 | **<L54-7> 3W MG Vibration** | 64.5d | 2026-06-01 | 2026-08-28 |  | 2026-10-13 | 2026-11-16 | 24d | 5d |  |  | 74h |  |
| 115 | 1.4.1.7.1 | <L54-7> 3W MG Vibration - Procure sensors - Pur. Req. | 0.25d | 2026-06-01 | 2026-06-01 | 108 | 2026-10-13 | 2026-11-03 | 15d | 45.25d | 0d | Alex | 2h | Alex |
| 116 | 1.4.1.7.2 | <L54-7> 3W MG Vibration - Procure sensors - Lead Time | 15d | 2026-06-01 | 2026-06-22 | 115 |  |  |  | 45.25d | 40.25d |  |  |  |
| 117 | 1.4.1.7.3 | <L54-7> 3W MG Vibration - Install sensors | 1d | 2026-08-18 | 2026-08-18 | 116, 22, 113 | 2026-11-03 | 2026-11-04 | 1d | 5d | 0d | Martin | 8h | Martin |
| 118 | 1.4.1.7.4 | <L54-7> 3W MG Vibration - Configure sensors | 1d | 2026-08-19 | 2026-08-19 | 117 | 2026-11-04 | 2026-11-05 | 1d | 5d | 0d | Alex | 8h | Justin |
| 119 | 1.4.1.7.5 | <L54-7> 3W MG Vibration - Configure dashboard | 1d | 2026-08-20 | 2026-08-20 | 118 | 2026-11-05 | 2026-11-06 | 1d | 5d | 0d | Alex | 8h | James |
| 120 | 1.4.1.7.6 | <L54-7> 3W MG Vibration - Record baseline data | 5d | 2026-08-21 | 2026-08-27 | 119 | 2026-11-06 | 2026-11-13 | 5d | 5d | 0d | Alex | 40h | Justin |
| 121 | 1.4.1.7.7 | <L54-7> 3W MG Vibration - Set alarm warning levels | 1d | 2026-08-28 | 2026-08-28 | 120 | 2026-11-13 | 2026-11-16 | 1d | 5d | 0d | James | 8h | James |
| 122 | 1.4.1.8 | **<L55-7> 4W MG Vibration** | 98d | 2026-06-02 | 2026-10-15 |  | 2026-10-13 | 2026-11-16 | 24d | 5d |  |  | 74h |  |
| 123 | 1.4.1.8.1 | <L55-7> 4W MG Vibration - Procure sensors - Pur. Req. | 0.25d | 2026-06-02 | 2026-06-02 | 115SS | 2026-10-13 | 2026-11-03 | 15d | 53.75d | 0d | Alex | 2h | Alex |
| 124 | 1.4.1.8.2 | <L55-7> 4W MG Vibration - Procure sensors - Lead Time | 15d | 2026-06-02 | 2026-06-23 | 123 |  |  |  | 53.75d | 0d |  |  |  |
| 125 | 1.4.1.8.3 | <L55-7> 4W MG Vibration - Install sensors | 1d | 2026-08-31 | 2026-08-31 | 124, 22, 121 | 2026-11-03 | 2026-11-04 | 1d | 5d | 0d | Martin | 8h | Martin |
| 126 | 1.4.1.8.4 | <L55-7> 4W MG Vibration - Configure sensors | 1d | 2026-09-01 | 2026-09-01 | 125 | 2026-11-04 | 2026-11-05 | 1d | 5d | 0d | Alex | 8h | Justin |
| 127 | 1.4.1.8.5 | <L55-7> 4W MG Vibration - Configure dashboard | 1d | 2026-09-02 | 2026-09-02 | 126 | 2026-11-05 | 2026-11-06 | 1d | 5d | 0d | Alex | 8h | James |
| 128 | 1.4.1.8.6 | <L55-7> 4W MG Vibration - Record baseline data | 5d | 2026-09-03 | 2026-09-09 | 127 | 2026-11-06 | 2026-11-13 | 5d | 5d | 0d | Alex | 40h | Justin |
| 129 | 1.4.1.8.7 | <L55-7> 4W MG Vibration - Set alarm warning levels | 1d | 2026-10-15 | 2026-10-15 | 128 | 2026-11-13 | 2026-11-16 | 1d | 5d | 0d | James | 8h | James |
| 130 | 1.4.1.9 | **<61-5> 6W MG Vibration** | 91.75d | 2026-06-23 | 2026-10-28 |  | 2026-11-03 | 2026-12-07 | 24d | 5d |  |  | 74h |  |
| 131 | 1.4.1.9.1 | <61-5> 6W MG Vibration - Procure sensors - Pur. Req. | 0.25d | 2026-06-23 | 2026-06-23 | 124 | 2026-11-03 | 2026-11-24 | 15d | 72.5d | 0d | Alex | 2h | Alex |
| 132 | 1.4.1.9.2 | <61-5> 6W MG Vibration - Procure sensors - Lead Time | 15d | 2026-06-23 | 2026-07-14 | 131 |  |  |  | 72.5d | 67.5d |  |  |  |
| 133 | 1.4.1.9.3 | <61-5> 6W MG Vibration - Install sensors | 1d | 2026-10-16 | 2026-10-16 | 132, 22, 129 | 2026-11-24 | 2026-11-25 | 1d | 5d | 0d | Martin | 8h | Martin |
| 134 | 1.4.1.9.4 | <61-5> 6W MG Vibration - Configure sensors | 1d | 2026-10-19 | 2026-10-19 | 133 | 2026-11-25 | 2026-11-26 | 1d | 5d | 0d | Alex | 8h | Justin |
| 135 | 1.4.1.9.5 | <61-5> 6W MG Vibration - Configure dashboard | 1d | 2026-10-20 | 2026-10-20 | 134 | 2026-11-26 | 2026-11-27 | 1d | 5d | 0d | Alex | 8h | James |
| 136 | 1.4.1.9.6 | <61-5> 6W MG Vibration - Record baseline data | 5d | 2026-10-21 | 2026-10-27 | 135 | 2026-11-27 | 2026-12-04 | 5d | 5d | 0d | Alex | 40h | Justin |
| 137 | 1.4.1.9.7 | <61-5> 6W MG Vibration - Set alarm warning levels | 1d | 2026-10-28 | 2026-10-28 | 136 | 2026-12-04 | 2026-12-07 | 1d | 5d | 0d | James | 8h | James |

Notes:
- 115: Purchase sensors for two pieces of equipment at a time to spread costs through time.
- 123: Purchase sensors for two pieces of equipment at a time to spread costs through time.
- 131: Purchase sensors for two pieces of equipment at a time to spread costs through time.

| ID | WBS | Task | Duration | Start | Finish | Predecessors | Baseline start | Baseline finish | Baseline duration | Total slack | Free slack | Resources | Work | Text1 |
| --- | --- | --- | --- | --- | --- | --- | --- | --- | --- | --- | --- | --- | --- | --- |
| 138 | 1.4.1.10 | **<AA90-8> Sound Test MG Vibration** | 116.25d | 2026-06-23 | 2026-12-02 |  | 2026-11-03 | 2026-12-07 | 24d | 5d | 0d |  | 74h |  |
| 139 | 1.4.1.10.1 | <AA90-8> Sound Test MG Vibration - Procure sensors - Pur. Req. | 0.25d | 2026-06-23 | 2026-06-23 | 131SS | 2026-11-03 | 2026-11-24 | 15d | 81d | 0d | Alex | 2h | Alex |
| 140 | 1.4.1.10.2 | <AA90-8> Sound Test MG Vibration - Procure sensors - Lead Time | 15d | 2026-06-24 | 2026-07-14 | 139 |  |  |  | 81d | 76d |  |  |  |
| 141 | 1.4.1.10.3 | <AA90-8> Sound Test MG Vibration - Install sensors | 1d | 2026-10-29 | 2026-10-29 | 140, 22, 137 | 2026-11-24 | 2026-11-25 | 1d | 5d | 0d | Martin | 8h | Martin |
| 142 | 1.4.1.10.4 | <AA90-8> Sound Test MG Vibration - Configure sensors | 1d | 2026-10-30 | 2026-10-30 | 141 | 2026-11-25 | 2026-11-26 | 1d | 5d | 0d | Alex | 8h | Justin |
| 143 | 1.4.1.10.5 | <AA90-8> Sound Test MG Vibration - Configure dashboard | 1d | 2026-11-02 | 2026-11-02 | 142 | 2026-11-26 | 2026-11-27 | 1d | 5d | 0d | Alex | 8h | James |
| 144 | 1.4.1.10.6 | <AA90-8> Sound Test MG Vibration - Record baseline data | 5d | 2026-11-03 | 2026-11-09 | 143 | 2026-11-27 | 2026-12-04 | 5d | 5d | 0d | Alex | 40h | Justin |
| 145 | 1.4.1.10.7 | <AA90-8> Sound Test MG Vibration - Set alarm warning levels | 1d | 2026-12-02 | 2026-12-02 | 144 | 2026-12-04 | 2026-12-07 | 1d | 5d |  | James | 8h | James |
| 146 | 1.4.2 | **Temperature Monitoring** | 167.25d | 2026-04-03 | 2026-11-24 | 28 | 2026-08-25 | 2026-12-18 | 84d | 11d |  |  | 580h |  |
| 147 | 1.4.2.1 | **<12-2> 50 Hz MG Temperature** | 63.25d | 2026-04-03 | 2026-07-01 |  | 2026-08-25 | 2026-09-25 | 24d | 13d |  |  | 58h |  |
| 148 | 1.4.2.1.1 | <12-2> 50 Hz MG Temperature - Procure sensors - Pur. Req. | 0.25d | 2026-04-03 | 2026-04-03 |  | 2026-08-25 | 2026-09-14 | 15d | 50.25d | 0d | Alex | 2h | Alex |
| 149 | 1.4.2.1.2 | <12-2> 50 Hz MG Temperature - Procure sensors - Lead Time | 15d | 2026-04-06 | 2026-04-24 | 148 |  |  |  | 54d | 41d |  |  |  |
| 150 | 1.4.2.1.3 | <12-2> 50 Hz MG Temperature - Install sensors | 1d | 2026-06-23 | 2026-06-23 | 149, 32 | 2026-09-15 | 2026-09-15 | 1d | 13d | 0d | Martin | 8h | Martin |
| 151 | 1.4.2.1.4 | <12-2> 50 Hz MG Temperature - Configure sensors | 1d | 2026-06-24 | 2026-06-24 | 150 | 2026-09-16 | 2026-09-16 | 1d | 13d | 0d | Justin | 8h | Justin |
| 152 | 1.4.2.1.5 | <12-2> 50 Hz MG Temperature - Configure dashboard | 1d | 2026-06-25 | 2026-06-25 | 151 | 2026-09-17 | 2026-09-17 | 1d | 13d | 0d | Justin | 8h | James |
| 153 | 1.4.2.1.6 | <12-2> 50 Hz MG Temperature - Record baseline data | 3d | 2026-06-26 | 2026-06-30 | 152 | 2026-09-18 | 2026-09-24 | 5d | 13d | 0d | James | 24h | Justin |
| 154 | 1.4.2.1.7 | <12-2> 50 Hz MG Temperature - Set alarm warning levels | 1d | 2026-07-01 | 2026-07-01 | 153 | 2026-09-25 | 2026-09-25 | 1d | 13d | 0d | Pat | 8h | James |
| 155 | 1.4.2.2 | **<4-3> 4E MG Temperature** | 70d | 2026-04-06 | 2026-07-10 |  | 2026-08-25 | 2026-09-25 | 24d | 13d |  |  | 58h |  |
| 156 | 1.4.2.2.1 | <4-3> 4E MG Temperature - Procure sensors - Pur. Req. | 0.25d | 2026-04-06 | 2026-04-06 | 148SS | 2026-08-25 | 2026-09-14 | 15d | 52.5d | 0d | Alex | 2h | Alex |
| 157 | 1.4.2.2.2 | <4-3> 4E MG Temperature - Procure sensors - Lead Time | 15d | 2026-04-06 | 2026-04-27 | 156 |  |  |  | 52.5d | 0d |  |  |  |
| 158 | 1.4.2.2.3 | <4-3> 4E MG Temperature - Install sensors | 1d | 2026-07-02 | 2026-07-02 | 157, 32, 154 | 2026-09-15 | 2026-09-15 | 1d | 13d | 0d | Martin | 8h | Martin |
| 159 | 1.4.2.2.4 | <4-3> 4E MG Temperature - Configure sensors | 1d | 2026-07-03 | 2026-07-03 | 158 | 2026-09-16 | 2026-09-16 | 1d | 13d | 0d | Justin | 8h | Justin |
| 160 | 1.4.2.2.5 | <4-3> 4E MG Temperature - Configure dashboard | 1d | 2026-07-06 | 2026-07-06 | 159 | 2026-09-17 | 2026-09-17 | 1d | 13d | 0d | Justin | 8h | James |
| 161 | 1.4.2.2.6 | <4-3> 4E MG Temperature - Record baseline data | 3d | 2026-07-07 | 2026-07-09 | 160 | 2026-09-18 | 2026-09-24 | 5d | 13d | 0d | James | 24h | Justin |
| 162 | 1.4.2.2.7 | <4-3> 4E MG Temperature - Set alarm warning levels | 1d | 2026-07-10 | 2026-07-10 | 161 | 2026-09-25 | 2026-09-25 | 1d | 13d | 0d | Pat | 8h | James |

Notes:
- 139: Purchase sensors for two pieces of equipment at a time to spread costs through time.
- 148: Purchase sensors for two pieces of equipment at a time to spread costs through time.
- 156: Purchase sensors for two pieces of equipment at a time to spread costs through time.

| ID | WBS | Task | Duration | Start | Finish | Predecessors | Baseline start | Baseline finish | Baseline duration | Total slack | Free slack | Resources | Work | Text1 |
| --- | --- | --- | --- | --- | --- | --- | --- | --- | --- | --- | --- | --- | --- | --- |
| 163 | 1.4.2.3 | **<5-3> 5E MG Temperature** | 77.75d | 2026-04-27 | 2026-08-12 |  | 2026-09-15 | 2026-10-16 | 24d | 12d | 9d |  | 58h |  |
| 164 | 1.4.2.3.1 | <5-3> 5E MG Temperature - Procure sensors - Pur. Req. | 0.25d | 2026-04-27 | 2026-04-27 | 157 | 2026-09-15 | 2026-10-05 | 15d | 52.5d | 0d | Alex | 2h | Alex |
| 165 | 1.4.2.3.2 | <5-3> 5E MG Temperature - Procure sensors - Lead Time | 15d | 2026-04-27 | 2026-05-18 | 164 |  |  |  | 52.5d | 39.5d |  |  |  |
| 166 | 1.4.2.3.3 | <5-3> 5E MG Temperature - Install sensors | 1d | 2026-07-13 | 2026-07-13 | 165, 32, 162 | 2026-10-06 | 2026-10-06 | 1d | 13d | 0d | Martin | 8h | Martin |
| 167 | 1.4.2.3.4 | <5-3> 5E MG Temperature - Configure sensors | 1d | 2026-08-04 | 2026-08-04 | 166 | 2026-10-07 | 2026-10-07 | 1d | 13d | 0d | Justin | 8h | Justin |
| 168 | 1.4.2.3.5 | <5-3> 5E MG Temperature - Configure dashboard | 1d | 2026-08-06 | 2026-08-06 | 167 | 2026-10-08 | 2026-10-08 | 1d | 12d | 0d | Justin | 8h | James |
| 169 | 1.4.2.3.6 | <5-3> 5E MG Temperature - Record baseline data | 3d | 2026-08-07 | 2026-08-11 | 168 | 2026-10-09 | 2026-10-15 | 5d | 12d | 0d | James | 24h | Justin |
| 170 | 1.4.2.3.7 | <5-3> 5E MG Temperature - Set alarm warning levels | 1d | 2026-08-12 | 2026-08-12 | 169 | 2026-10-16 | 2026-10-16 | 1d | 12d | 0d | Pat | 8h | James |
| 171 | 1.4.2.4 | **<6-3> 6E MG Temperature** | 78d | 2026-05-11 | 2026-08-26 |  | 2026-09-15 | 2026-10-16 | 24d | 13d | 7d |  | 58h |  |
| 172 | 1.4.2.4.1 | <6-3> 6E MG Temperature - Procure sensors - Pur. Req. | 0.25d | 2026-05-11 | 2026-05-11 | 164SS | 2026-09-15 | 2026-10-05 | 15d | 60.5d | 0d | Alex | 2h | Alex |
| 173 | 1.4.2.4.2 | <6-3> 6E MG Temperature - Procure sensors - Lead Time | 15d | 2026-05-11 | 2026-06-01 | 172 |  |  |  | 60.5d | 0d |  |  |  |
| 174 | 1.4.2.4.3 | <6-3> 6E MG Temperature - Install sensors | 1d | 2026-08-13 | 2026-08-13 | 173, 32, 170 | 2026-10-06 | 2026-10-06 | 1d | 12d | 0d | Martin | 8h | Martin |
| 175 | 1.4.2.4.4 | <6-3> 6E MG Temperature - Configure sensors | 1d | 2026-08-17 | 2026-08-17 | 174 | 2026-10-07 | 2026-10-07 | 1d | 14d | 0d | Justin | 8h | Justin |
| 176 | 1.4.2.4.5 | <6-3> 6E MG Temperature - Configure dashboard | 1d | 2026-08-19 | 2026-08-19 | 175 | 2026-10-08 | 2026-10-08 | 1d | 14d | 0d | Justin | 8h | James |
| 177 | 1.4.2.4.6 | <6-3> 6E MG Temperature - Record baseline data | 3d | 2026-08-20 | 2026-08-24 | 176 | 2026-10-09 | 2026-10-15 | 5d | 14d | 0d | James | 24h | Justin |
| 178 | 1.4.2.4.7 | <6-3> 6E MG Temperature - Set alarm warning levels | 1d | 2026-08-26 | 2026-08-26 | 177 | 2026-10-16 | 2026-10-16 | 1d | 13d | 0d | Pat | 8h | James |
| 179 | 1.4.2.5 | **<L53-4> 1W MG Temperature** | 70.75d | 2026-06-01 | 2026-09-07 |  | 2026-10-06 | 2026-11-06 | 24d | 13d | 7d |  | 58h |  |
| 180 | 1.4.2.5.1 | <L53-4> 1W MG Temperature - Procure sensors - Pur. Req. | 0.25d | 2026-06-01 | 2026-06-01 | 173 | 2026-10-06 | 2026-10-26 | 15d | 60.5d | 0d | Alex | 2h | Alex |
| 181 | 1.4.2.5.2 | <L53-4> 1W MG Temperature - Procure sensors - Lead Time | 15d | 2026-06-01 | 2026-06-22 | 180 |  |  |  | 60.5d | 47.5d |  |  |  |
| 182 | 1.4.2.5.3 | <L53-4> 1W MG Temperature - Install sensors | 1d | 2026-08-27 | 2026-08-27 | 181, 32, 178 | 2026-10-27 | 2026-10-27 | 1d | 13d | 0d | Martin | 8h | Martin |
| 183 | 1.4.2.5.4 | <L53-4> 1W MG Temperature - Configure sensors | 1d | 2026-08-28 | 2026-08-28 | 182 | 2026-10-28 | 2026-10-28 | 1d | 13d | 0d | Justin | 8h | Justin |
| 184 | 1.4.2.5.5 | <L53-4> 1W MG Temperature - Configure dashboard | 1d | 2026-09-01 | 2026-09-01 | 183 | 2026-10-29 | 2026-10-29 | 1d | 13d | 0d | Justin | 8h | James |
| 185 | 1.4.2.5.6 | <L53-4> 1W MG Temperature - Record baseline data | 3d | 2026-09-02 | 2026-09-04 | 184 | 2026-10-30 | 2026-11-05 | 5d | 13d | 0d | James | 24h | Justin |
| 186 | 1.4.2.5.7 | <L53-4> 1W MG Temperature - Set alarm warning levels | 1d | 2026-09-07 | 2026-09-07 | 185 | 2026-11-06 | 2026-11-06 | 1d | 13d | 0d | Pat | 8h | James |

Notes:
- 172: Purchase sensors for two pieces of equipment at a time to spread costs through time.
- 180: Purchase sensors for two pieces of equipment at a time to spread costs through time.

| ID | WBS | Task | Duration | Start | Finish | Predecessors | Baseline start | Baseline finish | Baseline duration | Total slack | Free slack | Resources | Work | Text1 |
| --- | --- | --- | --- | --- | --- | --- | --- | --- | --- | --- | --- | --- | --- | --- |
| 187 | 1.4.2.6 | **<L52-4> 2W MG Temperature** | 79.25d | 2026-06-01 | 2026-09-18 |  | 2026-10-06 | 2026-11-06 | 24d | 14d | 5d |  | 58h |  |
| 188 | 1.4.2.6.1 | <L52-4> 2W MG Temperature - Procure sensors - Pur. Req. | 0.25d | 2026-06-01 | 2026-06-01 | 180SS | 2026-10-06 | 2026-10-26 | 15d | 62.75d | 0d | Alex | 2h | Alex |
| 189 | 1.4.2.6.2 | <L52-4> 2W MG Temperature - Procure sensors - Lead Time | 15d | 2026-06-02 | 2026-06-22 | 188 |  |  |  | 62.75d | 0d |  |  |  |
| 190 | 1.4.2.6.3 | <L52-4> 2W MG Temperature - Install sensors | 1d | 2026-09-08 | 2026-09-08 | 189, 32, 186 | 2026-10-27 | 2026-10-27 | 1d | 13d | 0d | Martin | 8h | Martin |
| 191 | 1.4.2.6.4 | <L52-4> 2W MG Temperature - Configure sensors | 1d | 2026-09-10 | 2026-09-10 | 190 | 2026-10-28 | 2026-10-28 | 1d | 12d | 0d | Justin | 8h | Justin |
| 192 | 1.4.2.6.5 | <L52-4> 2W MG Temperature - Configure dashboard | 1d | 2026-09-14 | 2026-09-14 | 191 | 2026-10-29 | 2026-10-29 | 1d | 14d | 0d | Justin | 8h | James |
| 193 | 1.4.2.6.6 | <L52-4> 2W MG Temperature - Record baseline data | 3d | 2026-09-15 | 2026-09-17 | 192 | 2026-10-30 | 2026-11-05 | 5d | 14d | 0d | James | 24h | Justin |
| 194 | 1.4.2.6.7 | <L52-4> 2W MG Temperature - Set alarm warning levels | 1d | 2026-09-18 | 2026-09-18 | 193 | 2026-11-06 | 2026-11-06 | 1d | 14d | 0d | Pat | 8h | James |
| 195 | 1.4.2.7 | **<L54-7> 3W MG Temperature** | 73d | 2026-06-23 | 2026-10-01 |  | 2026-10-27 | 2026-11-27 | 24d | 13d | 2d |  | 58h |  |
| 196 | 1.4.2.7.1 | <L54-7> 3W MG Temperature - Procure sensors - Pur. Req. | 0.25d | 2026-06-23 | 2026-06-23 | 189 | 2026-10-27 | 2026-11-16 | 15d | 62.75d | 0d | Alex | 2h | Alex |
| 197 | 1.4.2.7.2 | <L54-7> 3W MG Temperature - Procure sensors - Lead Time | 15d | 2026-06-23 | 2026-07-14 | 196 |  |  |  | 62.75d | 48.75d |  |  |  |
| 198 | 1.4.2.7.3 | <L54-7> 3W MG Temperature - Install sensors | 1d | 2026-09-21 | 2026-09-21 | 197, 32, 194 | 2026-11-17 | 2026-11-17 | 1d | 14d | 0d | Martin | 8h | Martin |
| 199 | 1.4.2.7.4 | <L54-7> 3W MG Temperature - Configure sensors | 1d | 2026-09-23 | 2026-09-23 | 198 | 2026-11-18 | 2026-11-18 | 1d | 13d | 0d | Justin | 8h | Justin |
| 200 | 1.4.2.7.5 | <L54-7> 3W MG Temperature - Configure dashboard | 1d | 2026-09-25 | 2026-09-25 | 199 | 2026-11-19 | 2026-11-19 | 1d | 13d | 0d | Justin | 8h | James |
| 201 | 1.4.2.7.6 | <L54-7> 3W MG Temperature - Record baseline data | 3d | 2026-09-28 | 2026-09-30 | 200 | 2026-11-20 | 2026-11-26 | 5d | 13d | 0d | James | 24h | Justin |
| 202 | 1.4.2.7.7 | <L54-7> 3W MG Temperature - Set alarm warning levels | 1d | 2026-10-01 | 2026-10-01 | 201 | 2026-11-27 | 2026-11-27 | 1d | 13d | 0d | Pat | 8h | James |
| 203 | 1.4.2.8 | **<L55-7> 4W MG Temperature** | 86.5d | 2026-06-23 | 2026-10-21 |  | 2026-10-27 | 2026-11-27 | 24d | 11d | 5d |  | 58h |  |
| 204 | 1.4.2.8.1 | <L55-7> 4W MG Temperature - Procure sensors - Pur. Req. | 0.25d | 2026-06-23 | 2026-06-23 | 196SS | 2026-10-27 | 2026-11-16 | 15d | 67d | 0d | Alex | 2h | Alex |
| 205 | 1.4.2.8.2 | <L55-7> 4W MG Temperature - Procure sensors - Lead Time | 15d | 2026-06-23 | 2026-07-14 | 204 |  |  |  | 67d | 0d |  |  |  |
| 206 | 1.4.2.8.3 | <L55-7> 4W MG Temperature - Install sensors | 1d | 2026-10-02 | 2026-10-02 | 205, 32, 202 | 2026-11-17 | 2026-11-17 | 1d | 13d | 0d | Martin | 8h | Martin |
| 207 | 1.4.2.8.4 | <L55-7> 4W MG Temperature - Configure sensors | 1d | 2026-10-05 | 2026-10-05 | 206 | 2026-11-18 | 2026-11-18 | 1d | 13d | 0d | Justin | 8h | Justin |
| 208 | 1.4.2.8.5 | <L55-7> 4W MG Temperature - Configure dashboard | 1d | 2026-10-06 | 2026-10-06 | 207 | 2026-11-19 | 2026-11-19 | 1d | 13d | 0d | Justin | 8h | James |
| 209 | 1.4.2.8.6 | <L55-7> 4W MG Temperature - Record baseline data | 3d | 2026-10-16 | 2026-10-20 | 208 | 2026-11-20 | 2026-11-26 | 5d | 11d | 0d | James | 24h | Justin |
| 210 | 1.4.2.8.7 | <L55-7> 4W MG Temperature - Set alarm warning levels | 1d | 2026-10-21 | 2026-10-21 | 209 | 2026-11-27 | 2026-11-27 | 1d | 11d | 0d | Pat | 8h | James |

Notes:
- 188: Purchase sensors for two pieces of equipment at a time to spread costs through time.
- 196: Purchase sensors for two pieces of equipment at a time to spread costs through time.
- 204: Purchase sensors for two pieces of equipment at a time to spread costs through time.

| ID | WBS | Task | Duration | Start | Finish | Predecessors | Baseline start | Baseline finish | Baseline duration | Total slack | Free slack | Resources | Work | Text1 |
| --- | --- | --- | --- | --- | --- | --- | --- | --- | --- | --- | --- | --- | --- | --- |
| 211 | 1.4.2.9 | **<61-5> 6W MG Temperature** | 82.25d | 2026-07-14 | 2026-11-05 |  | 2026-11-17 | 2026-12-18 | 24d | 11d | 1d |  | 58h |  |
| 212 | 1.4.2.9.1 | <61-5> 6W MG Temperature - Procure sensors - Pur. Req. | 0.25d | 2026-07-14 | 2026-07-14 | 205 | 2026-11-17 | 2026-12-07 | 15d | 67d | 0d | Alex | 2h | Alex |
| 213 | 1.4.2.9.2 | <61-5> 6W MG Temperature - Procure sensors - Lead Time | 15d | 2026-07-15 | 2026-08-04 | 212 |  |  |  | 67d | 56d |  |  |  |
| 214 | 1.4.2.9.3 | <61-5> 6W MG Temperature - Install sensors | 1d | 2026-10-22 | 2026-10-22 | 213, 32, 210 | 2026-12-08 | 2026-12-08 | 1d | 11d | 0d | Martin | 8h | Martin |
| 215 | 1.4.2.9.4 | <61-5> 6W MG Temperature - Configure sensors | 1d | 2026-10-28 | 2026-10-28 | 214 | 2026-12-09 | 2026-12-09 | 1d | 12d | 0d | Justin | 8h | Justin |
| 216 | 1.4.2.9.5 | <61-5> 6W MG Temperature - Configure dashboard | 1d | 2026-10-30 | 2026-10-30 | 215 | 2026-12-10 | 2026-12-10 | 1d | 11d | 0d | Justin | 8h | James |
| 217 | 1.4.2.9.6 | <61-5> 6W MG Temperature - Record baseline data | 3d | 2026-11-02 | 2026-11-04 | 216 | 2026-12-11 | 2026-12-17 | 5d | 11d | 0d | James | 24h | Justin |
| 218 | 1.4.2.9.7 | <61-5> 6W MG Temperature - Set alarm warning levels | 1d | 2026-11-05 | 2026-11-05 | 217 | 2026-12-18 | 2026-12-18 | 1d | 11d | 0d | Pat | 8h | James |
| 219 | 1.4.2.10 | **<AA90-8> Sound Test MG Temperature** | 90d | 2026-07-22 | 2026-11-24 |  | 2026-11-17 | 2026-12-18 | 24d | 11d | 6d |  | 58h |  |
| 220 | 1.4.2.10.1 | <AA90-8> Sound Test MG Temperature - Procure sensors - Pur. Req. | 0.25d | 2026-07-22 | 2026-07-22 | 212SS | 2026-11-17 | 2026-12-07 | 15d | 72.75d | 0d | Alex | 2h | Alex |
| 221 | 1.4.2.10.2 | <AA90-8> Sound Test MG Temperature - Procure sensors - Lead Time | 15d | 2026-07-22 | 2026-08-12 | 220 |  |  |  | 72.75d | 61.75d |  |  |  |
| 222 | 1.4.2.10.3 | <AA90-8> Sound Test MG Temperature - Install sensors | 1d | 2026-11-06 | 2026-11-06 | 221, 32, 218 | 2026-12-08 | 2026-12-08 | 1d | 11d | 0d | Justin | 8h | Martin |
| 223 | 1.4.2.10.4 | <AA90-8> Sound Test MG Temperature - Configure sensors | 1d | 2026-11-10 | 2026-11-10 | 222 | 2026-12-09 | 2026-12-09 | 1d | 11d | 0d | Justin | 8h | Justin |
| 224 | 1.4.2.10.5 | <AA90-8> Sound Test MG Temperature - Configure dashboard | 1d | 2026-11-12 | 2026-11-12 | 223 | 2026-12-10 | 2026-12-10 | 1d | 11d | 0d | Justin | 8h | James |
| 225 | 1.4.2.10.6 | <AA90-8> Sound Test MG Temperature - Record baseline data | 3d | 2026-11-19 | 2026-11-23 | 224 | 2026-12-11 | 2026-12-17 | 5d | 11d | 0d | James | 24h | Justin |
| 226 | 1.4.2.10.7 | <AA90-8> Sound Test MG Temperature - Set alarm warning levels | 1d | 2026-11-24 | 2026-11-24 | 225 | 2026-12-18 | 2026-12-18 | 1d | 11d |  | James | 8h | James |
| 227 | 1.4.3 | **Branch circuit Power Monitoring** | 162.75d | 2026-04-17 | 2026-12-01 | 40 | 2026-08-07 | 2026-08-19 | 8d | 6d |  |  | 144h |  |
| 228 | 1.4.3.1 | **<7-2> 60 Hz Branch Monitoring** | 156.75d | 2026-04-23 | 2026-11-27 |  | 2026-08-07 | 2026-08-14 | 5d | 8d | 0d |  | 40h |  |
| 229 | 1.4.3.1.1 | <7-2> 60 Hz Branch Monitoring - Identify installation location | 3d | 2026-04-23 | 2026-04-28 |  | 2026-08-07 | 2026-08-12 | 3d | 9.75d | 0d | Pat | 24h | Pat |
| 230 | 1.4.3.1.2 | <7-2> 60 Hz Branch Monitoring - Install power monitoring hardware | 1d | 2026-05-01 | 2026-05-04 | 229 | 2026-08-12 | 2026-08-13 | 1d | 9.25d | 0d | Martin | 8h | Martin |
| 231 | 1.4.3.1.3 | <7-2> 60 Hz Branch Monitoring - Configure Communications from instrument to database | 1d | 2026-11-27 | 2026-11-27 | 230 | 2026-08-13 | 2026-08-14 | 1d | 8d |  | James | 8h | James |
| 232 | 1.4.3.2 | **<7-4> 50 Hz Branch Monitoring** | 162.75d | 2026-04-17 | 2026-12-01 |  | 2026-08-07 | 2026-08-19 | 8d | 6d | 0d |  | 64h |  |
| 233 | 1.4.3.2.1 | <7-4> 50 Hz Branch Monitoring - Identify installation location | 3d | 2026-04-17 | 2026-04-22 |  | 2026-08-07 | 2026-08-12 | 3d | 7.75d | 0d | Pat | 24h | Pat |
| 234 | 1.4.3.2.2 | <7-4> 50 Hz Branch Monitoring - Install power monitoring hardware | 3d | 2026-04-24 | 2026-04-29 | 233 | 2026-08-12 | 2026-08-17 | 3d | 6d | 0d | Martin | 24h | Martin |
| 235 | 1.4.3.2.3 | <7-4> 50 Hz Branch Monitoring - Configure Communications from instrument to database | 2d | 2026-11-30 | 2026-12-01 | 234 | 2026-08-17 | 2026-08-19 | 2d | 6d |  | James | 16h | James |

Notes:
- 212: Purchase sensors for two pieces of equipment at a time to spread costs through time.
- 220: Purchase sensors for two pieces of equipment at a time to spread costs through time.

| ID | WBS | Task | Duration | Start | Finish | Predecessors | Baseline start | Baseline finish | Baseline duration | Total slack | Free slack | Resources | Work | Text1 |
| --- | --- | --- | --- | --- | --- | --- | --- | --- | --- | --- | --- | --- | --- | --- |
| 236 | 1.4.3.3 | **<12-2> 50 Hz MG Monitoring** | 156.75d | 2026-04-22 | 2026-11-26 |  | 2026-08-07 | 2026-08-14 | 5d | 9d | 0d |  | 40h |  |
| 237 | 1.4.3.3.1 | <12-2> 50 Hz MG Monitoring - Identify installation location | 1d | 2026-04-22 | 2026-04-23 |  | 2026-08-07 | 2026-08-10 | 1d | 9d | 0d | Pat | 8h | Pat |
| 238 | 1.4.3.3.2 | <12-2> 50 Hz MG Monitoring - Install power monitoring hardware | 2d | 2026-04-29 | 2026-05-01 | 237 | 2026-08-10 | 2026-08-12 | 2d | 9d | 0d | Martin | 16h | Martin |
| 239 | 1.4.3.3.3 | <12-2> 50 Hz MG Monitoring - Configure Communications from instrument to database | 2d | 2026-11-25 | 2026-11-26 | 238 | 2026-08-12 | 2026-08-14 | 2d | 9d |  | James | 16h | James |
| 240 | 1.4.4 | **MG Power Monitoring** | 76d | 2026-08-05 | 2026-11-18 | 53 | 2026-11-10 | 2026-11-17 | 6d | 15d |  |  | 432h |  |
| 241 | 1.4.4.1 | **<4-3> 4E MG Power Monitoring** | 7d | 2026-08-05 | 2026-08-13 |  | 2026-11-10 | 2026-11-17 | 6d | 16d | 0d |  | 48h |  |
| 242 | 1.4.4.1.1 | <4-3> 4E MG Power Monitoring - Install hardware if required | 1d | 2026-08-05 | 2026-08-05 |  | 2026-11-10 | 2026-11-10 | 1d | 17d | 0d | Justin | 8h | Martin |
| 243 | 1.4.4.1.2 | <4-3> 4E MG Power Monitoring - Install Revised MG Starter Application | 1d | 2026-08-07 | 2026-08-07 | 242 | 2026-11-11 | 2026-11-11 | 1d | 16d | 0d | Justin | 8h | Justin |
| 244 | 1.4.4.1.3 | <4-3> 4E MG Power Monitoring - Install revised dyne application | 1d | 2026-08-10 | 2026-08-10 | 243 | 2026-11-12 | 2026-11-12 | 1d | 16d | 0d | Justin | 8h | Justin |
| 245 | 1.4.4.1.4 | <4-3> 4E MG Power Monitoring - Configure dashboard | 1d | 2026-08-11 | 2026-08-11 | 244 | 2026-11-13 | 2026-11-13 | 1d | 16d | 0d | Justin | 8h | James |
| 246 | 1.4.4.1.5 | <4-3> 4E MG Power Monitoring - Record baseline data | 1d | 2026-08-12 | 2026-08-12 | 245 | 2026-11-16 | 2026-11-16 | 1d | 16d | 0d | Justin | 8h | Justin |
| 247 | 1.4.4.1.6 | <4-3> 4E MG Power Monitoring - Set alarm warning levels | 1d | 2026-08-13 | 2026-08-13 | 246 | 2026-11-17 | 2026-11-17 | 1d | 16d |  | Pat | 8h | James |
| 248 | 1.4.4.2 | **<5-3> 5E MG Power Monitoring** | 8d | 2026-08-14 | 2026-08-25 | 241 | 2026-11-10 | 2026-11-17 | 6d | 16d | 0d |  | 48h |  |
| 249 | 1.4.4.2.1 | <5-3> 5E MG Power Monitoring - Install hardware if required | 1d | 2026-08-14 | 2026-08-14 |  | 2026-11-10 | 2026-11-10 | 1d | 16d | 0d | Justin | 8h | Martin |
| 250 | 1.4.4.2.2 | <5-3> 5E MG Power Monitoring - Install Revised MG Starter Application | 1d | 2026-08-18 | 2026-08-18 | 249 | 2026-11-11 | 2026-11-11 | 1d | 16d | 0d | Justin | 8h | Justin |
| 251 | 1.4.4.2.3 | <5-3> 5E MG Power Monitoring - Install revised dyne application | 1d | 2026-08-20 | 2026-08-20 | 250 | 2026-11-12 | 2026-11-12 | 1d | 16d | 0d | Justin | 8h | Justin |
| 252 | 1.4.4.2.4 | <5-3> 5E MG Power Monitoring - Configure dashboard | 1d | 2026-08-21 | 2026-08-21 | 251 | 2026-11-13 | 2026-11-13 | 1d | 16d | 0d | Justin | 8h | James |
| 253 | 1.4.4.2.5 | <5-3> 5E MG Power Monitoring - Record baseline data | 1d | 2026-08-24 | 2026-08-24 | 252 | 2026-11-16 | 2026-11-16 | 1d | 16d | 0d | Justin | 8h | Justin |
| 254 | 1.4.4.2.6 | <5-3> 5E MG Power Monitoring - Set alarm warning levels | 1d | 2026-08-25 | 2026-08-25 | 253 | 2026-11-17 | 2026-11-17 | 1d | 16d |  | Pat | 8h | James |
| 255 | 1.4.4.3 | **<6-3> 6E MG Power Monitoring** | 8d | 2026-08-26 | 2026-09-04 | 248 | 2026-11-10 | 2026-11-17 | 6d | 16d | 0d |  | 48h |  |
| 256 | 1.4.4.3.1 | <6-3> 6E MG Power Monitoring - Install hardware if required | 1d | 2026-08-26 | 2026-08-26 |  | 2026-11-10 | 2026-11-10 | 1d | 16d | 0d | Justin | 8h | Martin |
| 257 | 1.4.4.3.2 | <6-3> 6E MG Power Monitoring - Install Revised MG Starter Application | 1d | 2026-08-27 | 2026-08-27 | 256 | 2026-11-11 | 2026-11-11 | 1d | 16d | 0d | Justin | 8h | Justin |
| 258 | 1.4.4.3.3 | <6-3> 6E MG Power Monitoring - Install revised dyne application | 1d | 2026-08-31 | 2026-08-31 | 257 | 2026-11-12 | 2026-11-12 | 1d | 17d | 0d | Justin | 8h | Justin |
| 259 | 1.4.4.3.4 | <6-3> 6E MG Power Monitoring - Configure dashboard | 1d | 2026-09-02 | 2026-09-02 | 258 | 2026-11-13 | 2026-11-13 | 1d | 17d | 0d | Justin | 8h | James |
| 260 | 1.4.4.3.5 | <6-3> 6E MG Power Monitoring - Record baseline data | 1d | 2026-09-03 | 2026-09-03 | 259 | 2026-11-16 | 2026-11-16 | 1d | 17d | 0d | Justin | 8h | Justin |
| 261 | 1.4.4.3.6 | <6-3> 6E MG Power Monitoring - Set alarm warning levels | 1d | 2026-09-04 | 2026-09-04 | 260 | 2026-11-17 | 2026-11-17 | 1d | 17d |  | Pat | 8h | James |

| ID | WBS | Task | Duration | Start | Finish | Predecessors | Baseline start | Baseline finish | Baseline duration | Total slack | Free slack | Resources | Work | Text1 |
| --- | --- | --- | --- | --- | --- | --- | --- | --- | --- | --- | --- | --- | --- | --- |
| 262 | 1.4.4.4 | **<L53-4> 1W MG Power Monitoring** | 8d | 2026-09-07 | 2026-09-16 | 255 | 2026-11-10 | 2026-11-17 | 6d | 16d | 0d |  | 48h |  |
| 263 | 1.4.4.4.1 | <L53-4> 1W MG Power Monitoring - Install hardware if required | 1d | 2026-09-07 | 2026-09-07 |  | 2026-11-10 | 2026-11-10 | 1d | 17d | 0d | Justin | 8h | Martin |
| 264 | 1.4.4.4.2 | <L53-4> 1W MG Power Monitoring - Install Revised dyne application | 1d | 2026-09-08 | 2026-09-08 | 263 | 2026-11-11 | 2026-11-11 | 1d | 17d | 0d | Justin | 8h | Justin |
| 265 | 1.4.4.4.3 | <L53-4> 1W MG Power Monitoring - Install revised dyne application | 1d | 2026-09-09 | 2026-09-09 | 264 | 2026-11-12 | 2026-11-12 | 1d | 17d | 0d | Justin | 8h | Justin |
| 266 | 1.4.4.4.4 | <L53-4> 1W MG Power Monitoring - Configure dashboard | 1d | 2026-09-11 | 2026-09-11 | 265 | 2026-11-13 | 2026-11-13 | 1d | 16d | 0d | Justin | 8h | James |
| 267 | 1.4.4.4.5 | <L53-4> 1W MG Power Monitoring - Record baseline data | 1d | 2026-09-15 | 2026-09-15 | 266 | 2026-11-16 | 2026-11-16 | 1d | 16d | 0d | Justin | 8h | Justin |
| 268 | 1.4.4.4.6 | <L53-4> 1W MG Power Monitoring - Set alarm warning levels | 1d | 2026-09-16 | 2026-09-16 | 267 | 2026-11-17 | 2026-11-17 | 1d | 16d |  | Pat | 8h | James |
| 269 | 1.4.4.5 | **<L52-4> 2W MG Power Monitoring** | 7d | 2026-09-17 | 2026-09-25 | 262 | 2026-11-10 | 2026-11-17 | 6d | 16d | 0d |  | 48h |  |
| 270 | 1.4.4.5.1 | <L52-4> 2W MG Power Monitoring - Install hardware if required | 1d | 2026-09-17 | 2026-09-17 |  | 2026-11-10 | 2026-11-10 | 1d | 16d | 0d | Justin | 8h | Martin |
| 271 | 1.4.4.5.2 | <L52-4> 2W MG Power Monitoring - Install Revised dyne application | 1d | 2026-09-18 | 2026-09-18 | 270 | 2026-11-11 | 2026-11-11 | 1d | 16d | 0d | Justin | 8h | Justin |
| 272 | 1.4.4.5.3 | <L52-4> 2W MG Power Monitoring - Install revised dyne application | 1d | 2026-09-21 | 2026-09-21 | 271 | 2026-11-12 | 2026-11-12 | 1d | 16d | 0d | Justin | 8h | Justin |
| 273 | 1.4.4.5.4 | <L52-4> 2W MG Power Monitoring - Configure dashboard | 1d | 2026-09-22 | 2026-09-22 | 272 | 2026-11-13 | 2026-11-13 | 1d | 16d | 0d | Justin | 8h | James |
| 274 | 1.4.4.5.5 | <L52-4> 2W MG Power Monitoring - Record baseline data | 1d | 2026-09-24 | 2026-09-24 | 273 | 2026-11-16 | 2026-11-16 | 1d | 16d | 0d | Justin | 8h | Justin |
| 275 | 1.4.4.5.6 | <L52-4> 2W MG Power Monitoring - Set alarm warning levels | 1d | 2026-09-25 | 2026-09-25 | 274 | 2026-11-17 | 2026-11-17 | 1d | 16d |  | Pat | 8h | James |
| 276 | 1.4.4.6 | **<L54-7> 3W MG Power Montoring** | 6d | 2026-09-28 | 2026-10-05 | 269 | 2026-11-10 | 2026-11-17 | 6d | 16d | 0d |  | 48h |  |
| 277 | 1.4.4.6.1 | <L54-7> 3W MG Power Montoring - Install hardware if required | 1d | 2026-09-28 | 2026-09-28 |  | 2026-11-10 | 2026-11-10 | 1d | 16d | 0d | Justin | 8h | Martin |
| 278 | 1.4.4.6.2 | <L54-7> 3W MG Power Montoring - Install Revised dyne application | 1d | 2026-09-29 | 2026-09-29 | 277 | 2026-11-11 | 2026-11-11 | 1d | 16d | 0d | Justin | 8h | Justin |
| 279 | 1.4.4.6.3 | <L54-7> 3W MG Power Montoring - Install revised dyne application | 1d | 2026-09-30 | 2026-09-30 | 278 | 2026-11-12 | 2026-11-12 | 1d | 16d | 0d | Justin | 8h | Justin |
| 280 | 1.4.4.6.4 | <L54-7> 3W MG Power Montoring - Configure dashboard | 1d | 2026-10-01 | 2026-10-01 | 279 | 2026-11-13 | 2026-11-13 | 1d | 16d | 0d | Justin | 8h | James |
| 281 | 1.4.4.6.5 | <L54-7> 3W MG Power Montoring - Record baseline data | 1d | 2026-10-02 | 2026-10-02 | 280 | 2026-11-16 | 2026-11-16 | 1d | 16d | 0d | Justin | 8h | Justin |
| 282 | 1.4.4.6.6 | <L54-7> 3W MG Power Montoring - Set alarm warning levels | 1d | 2026-10-05 | 2026-10-05 | 281 | 2026-11-17 | 2026-11-17 | 1d | 16d |  | Pat | 8h | James |
| 283 | 1.4.4.7 | **<L55-7> 4W MG Power Monitoring** | 16d | 2026-10-07 | 2026-10-28 | 276 | 2026-11-10 | 2026-11-17 | 6d | 15d | 0d |  | 48h |  |
| 284 | 1.4.4.7.1 | <L55-7> 4W MG Power Monitoring - Install hardware if required | 1d | 2026-10-07 | 2026-10-07 |  | 2026-11-10 | 2026-11-10 | 1d | 15d | 0d | Justin | 8h | Martin |
| 285 | 1.4.4.7.2 | <L55-7> 4W MG Power Monitoring - Install Revised dyne application | 1d | 2026-10-08 | 2026-10-08 | 284 | 2026-11-11 | 2026-11-11 | 1d | 15d | 0d | Justin | 8h | Justin |
| 286 | 1.4.4.7.3 | <L55-7> 4W MG Power Monitoring - Install revised dyne application | 1d | 2026-10-23 | 2026-10-23 | 285 | 2026-11-12 | 2026-11-12 | 1d | 15d | 0d | Justin | 8h | Justin |
| 287 | 1.4.4.7.4 | <L55-7> 4W MG Power Monitoring - Configure dashboard | 1d | 2026-10-26 | 2026-10-26 | 286 | 2026-11-13 | 2026-11-13 | 1d | 15d | 0d | Justin | 8h | James |
| 288 | 1.4.4.7.5 | <L55-7> 4W MG Power Monitoring - Record baseline data | 1d | 2026-10-27 | 2026-10-27 | 287 | 2026-11-16 | 2026-11-16 | 1d | 15d | 0d | Justin | 8h | Justin |
| 289 | 1.4.4.7.6 | <L55-7> 4W MG Power Monitoring - Set alarm warning levels | 1d | 2026-10-28 | 2026-10-28 | 288 | 2026-11-17 | 2026-11-17 | 1d | 15d |  | Pat | 8h | James |

| ID | WBS | Task | Type | Duration | Start | Finish | Predecessors | Baseline start | Baseline finish | Baseline duration | Total slack | Free slack | Resources | Work | Text1 |
| --- | --- | --- | --- | --- | --- | --- | --- | --- | --- | --- | --- | --- | --- | --- | --- |
| 290 | 1.4.4.8 | **<61-5> 6W MG Power Monitoring** |  | 7d | 2026-10-29 | 2026-11-06 | 283 | 2026-11-10 | 2026-11-17 | 6d | 15d | 0d |  | 48h |  |
| 291 | 1.4.4.8.1 | <61-5> 6W MG Power Monitoring - Install hardware if required |  | 1d | 2026-10-29 | 2026-10-29 |  | 2026-11-10 | 2026-11-10 | 1d | 15d | 0d | Justin | 8h | Martin |
| 292 | 1.4.4.8.2 | <61-5> 6W MG Power Monitoring - Install Revised dyne application |  | 1d | 2026-11-02 | 2026-11-02 | 291 | 2026-11-11 | 2026-11-11 | 1d | 15d | 0d | Justin | 8h | Justin |
| 293 | 1.4.4.8.3 | <61-5> 6W MG Power Monitoring - Install revised dyne application |  | 1d | 2026-11-03 | 2026-11-03 | 292 | 2026-11-12 | 2026-11-12 | 1d | 15d | 0d | Justin | 8h | Justin |
| 294 | 1.4.4.8.4 | <61-5> 6W MG Power Monitoring - Configure dashboard |  | 1d | 2026-11-04 | 2026-11-04 | 293 | 2026-11-13 | 2026-11-13 | 1d | 15d | 0d | Justin | 8h | James |
| 295 | 1.4.4.8.5 | <61-5> 6W MG Power Monitoring - Record baseline data |  | 1d | 2026-11-05 | 2026-11-05 | 294 | 2026-11-16 | 2026-11-16 | 1d | 15d | 0d | Justin | 8h | Justin |
| 296 | 1.4.4.8.6 | <61-5> 6W MG Power Monitoring - Set alarm warning levels |  | 1d | 2026-11-06 | 2026-11-06 | 295 | 2026-11-17 | 2026-11-17 | 1d | 15d |  | Pat | 8h | James |
| 297 | 1.4.4.9 | **<AA90-8> Sound Test MG Power Monitoring** |  | 8d | 2026-11-09 | 2026-11-18 | 290 | 2026-11-10 | 2026-11-17 | 6d | 15d | 10d |  | 48h |  |
| 298 | 1.4.4.9.1 | <AA90-8> Sound Test MG Power Monitoring - Install hardware if required |  | 1d | 2026-11-09 | 2026-11-09 |  | 2026-11-10 | 2026-11-10 | 1d | 15d | 0d | Justin | 8h | Martin |
| 299 | 1.4.4.9.2 | <AA90-8> Sound Test MG Power Monitoring - Install Revised dyne application |  | 1d | 2026-11-11 | 2026-11-11 | 298 | 2026-11-11 | 2026-11-11 | 1d | 15d | 0d | Justin | 8h | Justin |
| 300 | 1.4.4.9.3 | <AA90-8> Sound Test MG Power Monitoring - Install revised dyne application |  | 1d | 2026-11-13 | 2026-11-13 | 299 | 2026-11-12 | 2026-11-12 | 1d | 15d | 0d | Justin | 8h | Justin |
| 301 | 1.4.4.9.4 | <AA90-8> Sound Test MG Power Monitoring - Configure dashboard |  | 1d | 2026-11-16 | 2026-11-16 | 300 | 2026-11-13 | 2026-11-13 | 1d | 15d | 0d | Justin | 8h | James |
| 302 | 1.4.4.9.5 | <AA90-8> Sound Test MG Power Monitoring - Record baseline data |  | 1d | 2026-11-17 | 2026-11-17 | 301 | 2026-11-16 | 2026-11-16 | 1d | 15d | 0d | Justin | 8h | Justin |
| 303 | 1.4.4.9.6 | <AA90-8> Sound Test MG Power Monitoring - Set alarm warning levels |  | 1d | 2026-11-18 | 2026-11-18 | 302 | 2026-11-17 | 2026-11-17 | 1d | 15d |  | Pat | 8h | James |
| 304 | 2 | **Milestones** |  | 79d | 2026-08-13 | 2026-12-02 |  | 2026-08-14 | 2026-12-18 | 90.75d | 5d |  |  |  |  |
| 305 | 2.1 | <7-2> 60 Hz Branch Monitoring Complete | milestone | 0d | 2026-11-27 | 2026-11-27 | 228 | 2026-08-14 | 2026-08-14 | 0d | 8d |  |  |  |  |
| 306 | 2.2 | <7-4> 50 Hz Branch Monitoring Complete | milestone | 0d | 2026-12-01 | 2026-12-01 | 232 | 2026-08-19 | 2026-08-19 | 0d | 6d |  |  |  |  |
| 307 | 2.3 | <12-2> 50 Hz MG Monitoring Complete | milestone | 0d | 2026-11-26 | 2026-11-26 | 66, 147, 236 | 2026-09-25 | 2026-09-25 | 0d | 9d |  |  |  |  |
| 308 | 2.4 | <4-3> 4E MG Monitoring Complete | milestone | 0d | 2026-08-13 | 2026-08-13 | 74, 155, 241 | 2026-11-17 | 2026-11-17 | 0d | 84d |  |  |  |  |
| 309 | 2.5 | <5-3> 5E MG Monitoring Complete | milestone | 0d | 2026-08-25 | 2026-08-25 | 82, 163, 248 | 2026-11-17 | 2026-11-17 | 0d | 76d |  |  |  |  |
| 310 | 2.6 | <6-3> 6E MG Monitoring Complete | milestone | 0d | 2026-09-04 | 2026-09-04 | 90, 171, 255 | 2026-11-17 | 2026-11-17 | 0d | 68d |  |  |  |  |
| 311 | 2.7 | <L53-4> 1W MG Monitoring Complete | milestone | 0d | 2026-09-16 | 2026-09-16 | 98, 179, 262 | 2026-11-17 | 2026-11-17 | 0d | 60d |  |  |  |  |
| 312 | 2.8 | <L52-4> 2W MG Monitoring Complete | milestone | 0d | 2026-09-25 | 2026-09-25 | 106, 187, 269 | 2026-11-17 | 2026-11-17 | 0d | 53d |  |  |  |  |
| 313 | 2.9 | <L54-7> 3W MG Montoring Complete | milestone | 0d | 2026-10-05 | 2026-10-05 | 114, 195, 276 | 2026-11-27 | 2026-11-27 | 0d | 47d |  |  |  |  |
| 314 | 2.10 | <L55-7> 4W MG Monitoring Complete | milestone | 0d | 2026-10-28 | 2026-10-28 | 122, 203, 283 | 2026-11-27 | 2026-11-27 | 0d | 30d |  |  |  |  |
| 315 | 2.11 | <61-5> 6W MG Monitoring Complete | milestone | 0d | 2026-11-06 | 2026-11-06 | 130, 211, 290 | 2026-12-18 | 2026-12-18 | 0d | 23d |  |  |  |  |
| 316 | 2.12 | <AA90-8> Sound Test MG Monitoring Complete | milestone | 0d | 2026-12-02 | 2026-12-02 | 138, 219, 297 | 2026-12-18 | 2026-12-18 | 0d | 5d |  |  |  |  |
